# Whole Project

Schedule from MS Project, 2003-10-24 to 2005-10-05, A marks actual dates.
Sanctuary
thequality.com

## Calendars

- Standard: Mon-Fri 09:30-13:00, 13:15-17:45; Sat-Sun off. Exceptions (off unless hours are given): 2003-10-24 08:00-12:00, 13:00-17:00, 2003-10-27 to 2003-10-31 08:00-12:00, 13:00-17:00, 2003-11-03 09:30-13:00, 13:15-17:45.

## Schedule

| ID | WBS | Task | Type | Duration | Start | Finish | Predecessors | Complete | Remaining | Baseline start | Baseline finish | Baseline duration | Total slack | Free slack | Constraint | Deadline | Work |
| --- | --- | --- | --- | --- | --- | --- | --- | --- | --- | --- | --- | --- | --- | --- | --- | --- | --- |
| 1 | 1 | **NESTA proposal** |  | 90d | 2003-10-24 A | 2004-02-26 |  | 26% | 66.45d |  |  |  | 0d |  |  |  |  |
| 2 | 1.1 | Finalise first draft of proposal |  | 2w | 2003-10-24 A | 2003-11-06 A |  | 100% |  |  |  |  |  |  |  |  |  |
| 3 | 1.2 | review proposal |  | 3.8w | 2003-10-27 A | 2003-11-20 | 2SS | 84% | 0.62w |  |  |  | 0d |  |  |  |  |
| 4 | 1.3 | Final Draft complete | milestone | 0d | 2003-11-20 | 2003-11-20 | 3 |  |  |  |  |  | 0d |  |  |  |  |
| 5 | 1.4 | Submit Full NESTA proposal | milestone | 0d | 2003-11-20 | 2003-11-20 | 4 |  |  | 2003-10-31 | 2003-10-31 | 0d | 0d |  |  | 2003-11-21 |  |
| 6 | 1.5 | NESTA full proposal through the mill |  | 14w | 2003-11-21 | 2004-02-26 | 5 |  |  |  |  |  | 0d |  |  |  |  |
| 7 | 1.6 | Receive instalment of funding | milestone | 0d | 2004-02-26 | 2004-02-26 | 6 |  |  | 2004-01-09 | 2004-01-09 | 0d | 0d |  | start no earlier than 2004-02-01 |  |  |
| 8 | 2 | **Build Team** |  | 173d | 2004-02-27 | 2004-10-26 |  |  |  |  |  |  | 0d |  |  |  | 8h |
| 9 | 2.1 | Advertise for sysadmin |  | 1d | 2004-02-27 | 2004-02-27 | 7 |  |  | 2003-10-31 | 2003-10-31 | 1d | 0d |  | start no earlier than 2004-01-05 |  |  |
| 10 | 2.2 | interview for sysadmin |  | 2w | 2004-03-01 | 2004-03-12 | 9 |  |  | 2003-11-03 | 2003-11-03 | 1d? | 0d |  |  |  |  |
| 11 | 2.3 | hire sysadmin |  | 1d | 2004-03-15 | 2004-03-15 | 10 |  |  | 2004-01-09 | 2004-01-09 | 1d | 0d |  |  |  |  |
| 12 | 2.4 | train up sysadmin |  | 2d | 2004-03-16 | 2004-03-17 | 11 |  |  | 2004-01-12 | 2004-01-12 | 1d? | 0d |  |  |  | 8h |
| 13 | 2.5 | advertise for project accountant |  | 1d | 2004-02-27 | 2004-02-27 | 7 |  |  | 2003-10-31 | 2003-10-31 | 1d? | 405d | 0d | start no earlier than 2004-01-05 |  |  |
| 14 | 2.6 | interview for project accountant |  | 2w | 2004-03-01 | 2004-03-12 | 13 |  |  | 2003-11-03 | 2003-11-03 | 1d? | 405d | 0d |  |  |  |
| 15 | 2.7 | hire project accountant |  | 1d | 2004-03-15 | 2004-03-15 | 14 |  |  | 2004-01-09 | 2004-01-09 | 1d | 405d | 2d |  |  |  |
| 16 | 2.8 | train project accountant |  | 2d | 2004-03-18 | 2004-03-19 | 15, 12 |  |  | 2004-01-12 | 2004-01-12 | 1d? | 403d |  |  |  |  |
| 17 | 2.9 | advertise for film production manager |  | 1d | 2004-02-27 | 2004-02-27 | 7 |  |  | 2003-10-31 | 2003-10-31 | 1d? | 2d | 0d | start no earlier than 2004-01-05 |  |  |
| 18 | 2.10 | interview for film production manager |  | 2w | 2004-03-01 | 2004-03-12 | 17 |  |  | 2003-11-03 | 2003-11-03 | 1d? | 2d | 0d |  |  |  |
| 19 | 2.11 | hire film production manager |  | 1d | 2004-03-15 | 2004-03-15 | 18 |  |  | 2004-01-09 | 2004-01-09 | 1d? | 2d |  |  |  |  |
| 20 | 2.12 | train film production manager |  | 5d | 2004-03-18 | 2004-03-24 | 19, 12 |  |  | 2004-01-12 | 2004-01-12 | 1d? | 0d |  |  |  |  |
| 21 | 2.13 | advertse for game production manager |  | 1d | 2004-10-04 | 2004-10-04 | 7 |  |  | 2003-10-31 | 2003-10-31 | 1d? | 246d | 0d | start no earlier than 2004-10-04 |  |  |
| 22 | 2.14 | interview for game production manager |  | 2w | 2004-10-05 | 2004-10-18 | 21 |  |  | 2003-11-03 | 2003-11-03 | 1d? | 246d | 0d |  |  |  |
| 23 | 2.15 | hire game production manager |  | 1d | 2004-10-19 | 2004-10-19 | 22 |  |  | 2004-01-09 | 2004-01-09 | 1d? | 246d | 0d |  |  |  |
| 24 | 2.16 | train game production manager |  | 5d | 2004-10-20 | 2004-10-26 | 23, 12 |  |  | 2004-01-12 | 2004-01-12 | 1d? | 246d |  |  |  |  |
| 25 | 2.17 | advertise for online production manager |  | 1d | 2004-02-27 | 2004-02-27 | 7 |  |  | 2003-10-31 | 2003-10-31 | 1d? | 402d | 0d | start no earlier than 2004-01-05 |  |  |
| 26 | 2.18 | interview online production manager |  | 2w | 2004-03-01 | 2004-03-12 | 25 |  |  | 2003-11-03 | 2003-11-03 | 1d? | 402d | 0d |  |  |  |
| 27 | 2.19 | hire online productio manager |  | 1d | 2004-03-15 | 2004-03-15 | 26 |  |  | 2004-01-09 | 2004-01-09 | 1d? | 402d | 2d |  |  |  |
| 28 | 2.20 | train online production manager |  | 5d | 2004-03-18 | 2004-03-24 | 27, 12 |  |  | 2004-01-12 | 2004-01-12 | 1d? | 400d |  |  |  |  |

| ID | WBS | Task | Type | Duration | Start | Finish | Predecessors | Total slack | Free slack | Constraint |
| --- | --- | --- | --- | --- | --- | --- | --- | --- | --- | --- |
| 29 | 3 | **Film Production (inc. Concept Art)** |  | 315d | 2004-03-25 | 2005-06-08 |  | 0d |  |  |
| 30 | 3.1 | Revise Sanctuary Script |  | 16w | 2004-03-25 | 2004-07-14 | 20 | 0d |  |  |
| 31 | 3.2 | Develop Concept Art |  | 16w | 2004-03-25 | 2004-07-14 | 20, 30SS | 80d |  |  |
| 32 | 3.3 | Develop Storyboards and Animatic |  | 16w | 2004-07-15 | 2004-11-03 | 20, 30, 31SS | 0d |  |  |
| 33 | 3.4 | Completion of Animatic | milestone | 0d | 2004-11-03 | 2004-11-03 | 32 | 0d |  |  |
| 34 | 3.5 | Pre-production |  | 17w | 2004-11-04 | 2005-03-02 | 33, 30, 31 | 0d |  |  |
| 35 | 3.6 | Day One of principal photography | milestone | 0d | 2005-03-02 | 2005-03-02 | 7, 34 | 0d |  | start no earlier than 2005-01-03 |
| 36 | 3.7 | Principal Photography |  | 2w | 2005-03-03 | 2005-03-16 | 35 | 0d |  |  |
| 37 | 3.8 | Sanctuary post-production (inc. 3-D + 360 Panorama) |  | 12w | 2005-03-17 | 2005-06-08 | 36 | 25d | 0d |  |
| 38 | 3.9 | Final Cut of Sanctuary | milestone | 0d | 2005-06-08 | 2005-06-08 | 37 | 25d | 0d |  |
| 39 | 4 | **Console and Online Production** |  | 240d | 2004-11-04 | 2005-10-05 |  | 0d |  |  |
| 40 | 4.1 | Development of IDDv.1 |  | 8w | 2004-11-04 | 2004-12-29 | 7, 34SS | 55d | 0d |  |
| 41 | 4.2 | Interactivity design document (IDD) v.1 | milestone | 0d | 2004-12-29 | 2004-12-29 | 40 | 55d |  |  |
| 42 | 4.3 | refinement of prototype IDD |  | 8w | 2005-03-17 | 2005-05-11 | 41, 36 | 0d |  |  |
| 43 | 4.4 | Finalisation of the interactivity design document | milestone | 0d | 2005-05-11 | 2005-05-11 | 42 | 0d |  |  |
| 44 | 4.5 | Programming of core product prototype |  | 8w | 2005-05-12 | 2005-07-06 | 43 | 0d |  |  |
| 45 | 4.6 | Alpha Testing |  | 3w | 2005-07-07 | 2005-07-27 | 44 | 0d |  |  |
| 46 | 4.7 | Refinement of prototype |  | 4w | 2005-07-28 | 2005-08-24 | 45, 53, 52 | 0d |  |  |
| 47 | 4.8 | Beta Testing |  | 3w | 2005-08-25 | 2005-09-14 | 46 | 0d |  |  |
| 48 | 4.9 | Further refinement of core product |  | 3w | 2005-09-15 | 2005-10-05 | 47 | 0d |  |  |
| 49 | 4.10 | Delivery of core product | milestone | 0d | 2005-10-05 | 2005-10-05 | 48 | 0d |  |  |
| 50 | 5 | **Marketing and Distribution** |  | 85d | 2005-06-09 | 2005-10-05 |  | 0d |  |  |
| 51 | 5.1 | Submission to first Festival |  | 2w | 2005-06-09 | 2005-06-22 | 38 | 25d | 0d |  |
| 52 | 5.2 | Community support site goes online | milestone | 0d | 2005-06-22 | 2005-06-22 | 51 | 25d |  |  |
| 53 | 5.3 | First public (festival) screening of Sanctuary | milestone | 0d | 2005-06-22 | 2005-06-22 | 51 | 25d |  |  |
| 54 | 5.4 | Core Product released | milestone | 0d | 2005-10-05 | 2005-10-05 | 53, 48 | 0d |  |  |
